Schedule from MS Project, 2005-01-27 to 2005-06-02, costs in €.

## Calendars

- Standard: Mon-Fri 08:00-12:00, 13:00-17:00; Sat-Sun off.

## Resources

| Resource | Group | Unit | Rate |
| --- | --- | --- | --- |
| Gestor de Projecto | Gestão |  | 75 |
| Servidor Alpha | Material | P IV x 2 | 5000 |
| Sponsor | Gestão |  | 100 |
| Analista Sénior | Técnica |  | 60 |
| Analista | Técnica |  | 50 |
| Analista Júnior | Técnica |  | 40 |
| Programador Sénior | Técnica |  | 60 |
| Programador | Técnica |  | 50 |
| Programador Júnior | Técnica |  | 40 |
| Técnico de Qualidade | Técnica |  | 50 |
| Testador Sénior | Técnica |  | 60 |
| Testador | Técnica |  | 50 |
| Viagem | Material | € | 1 |

## Schedule

| ID | WBS | Task | Type | Duration | Start | Finish | Predecessors | Total slack | Free slack | Constraint | Resources | Work | Cost |
| --- | --- | --- | --- | --- | --- | --- | --- | --- | --- | --- | --- | --- | --- |
| 1 | 1 | **Constraint Table** |  | 29.08d | 2005-01-27 | 2005-03-09 |  | 0d |  |  |  |  |  |
| 2 | 1.1 | Adjudicação do projecto | milestone | 0d | 2005-01-27 | 2005-01-27 |  | 0d |  |  |  |  |  |
| 3 | 1.2 | Recepção do Modelo Dimensional | milestone | 0d | 2005-02-18 | 2005-02-18 | 76FS+5d | 0d |  |  |  |  |  |
| 4 | 1.3 | Recepção do Módulo de Exportação de Dados | milestone | 0d | 2005-03-04 | 2005-03-04 | 77FS+5d | 0d |  |  |  |  |  |
| 5 | 1.4 | Recepção do Módulo de Análise Parametrizado | milestone | 0d | 2005-03-09 | 2005-03-09 | 78FS+5d | 59.79d | 0d |  |  |  |  |
| 6 | 1.5 | Recepção do Servidor | milestone | 0d | 2005-02-28 | 2005-02-28 |  | 0d |  | must start on 2005-02-28 |  |  |  |
| 7 | 2 | **Sistema Aplicacional** |  | 90.87d? | 2005-01-27 | 2005-06-02 | 2 | 0d |  |  |  | 1288.38h | 79,047.47 |
| 8 | 2.1 | **Gestão de Projecto** |  | 90.87d? | 2005-01-27 | 2005-06-02 |  | 0d |  |  |  | 452.38h | 32,668.8 |
| 9 | 2.1.1 | **Planeamento** |  | 8d? | 2005-01-27 | 2005-02-07 |  | 0d |  |  |  | 128h | 9,280 |
| 10 | 2.1.1.1 | **PBS (2.2.1.1)** |  | 4d? | 2005-01-27 | 2005-02-01 |  | 0d |  |  |  | 64h | 4,640 |
| 11 | 2.1.1.1.1 | Elaborar versão Draft |  | 2d | 2005-01-27 | 2005-01-28 |  | 0d |  |  | Gestor de Projecto | 16h | 1,200 |
| 12 | 2.1.1.1.2 | Rever com a Equipa |  | 2d? | 2005-01-31 | 2005-02-01 | 11 | 0d |  |  | Gestor de Projecto [50%]; Analista Sénior; Programador Sénior; Testador Sénior | 32h | 2,040 |
| 13 | 2.1.1.1.3 | Validar com o Sponsor e com o Cliente |  | 2d? | 2005-01-31 | 2005-02-01 | 12FF | 0d |  |  | Gestor de Projecto [50%]; Sponsor | 16h | 1,400 |
| 14 | 2.1.1.2 | **Plano Interno (2.2.1.2)** |  | 4d? | 2005-02-02 | 2005-02-07 | 10 | 0d |  |  |  | 64h | 4,640 |
| 15 | 2.1.1.2.1 | Elaborar versão Draft |  | 2d? | 2005-02-02 | 2005-02-03 |  | 0d |  |  | Gestor de Projecto | 16h | 1,200 |
| 16 | 2.1.1.2.2 | Rever com a Equipa |  | 2d? | 2005-02-04 | 2005-02-07 | 15 | 0d |  |  | Gestor de Projecto [50%]; Analista Sénior; Programador Sénior; Testador Sénior | 32h | 2,040 |
| 17 | 2.1.1.2.3 | Validar com o Sponsor e com o Cliente |  | 2d? | 2005-02-04 | 2005-02-07 | 16FF | 0d |  |  | Gestor de Projecto [50%]; Sponsor | 16h | 1,400 |
| 18 | 2.1.2 | **Controlo** |  | 81.37d? | 2005-02-08 | 2005-06-01 | 25SS | 0d |  |  |  | 260.38h | 19,528.8 |
| 19 | 2.1.2.1 | Relatórios ao Cliente (2.2.2.1) |  | 81.37d? | 2005-02-08 | 2005-06-01 |  | 0d |  |  | Gestor de Projecto [20%] | 130.19h | 9,764.4 |
| 20 | 2.1.2.2 | Métricas (2.2.2.2) |  | 81.37d? | 2005-02-08 | 2005-06-01 |  | 0d |  |  | Gestor de Projecto [20%] | 130.19h | 9,764.4 |
| 21 | 2.1.3 | **Encerramento** |  | 1.5d? | 2005-06-01 | 2005-06-02 | 25, 18 | 0d |  |  |  | 64h | 3,860 |
| 22 | 2.1.3.1 | Lessons Learned (2.2.3.1) |  | 0.5d? | 2005-06-01 | 2005-06-01 |  | 0d |  |  | Gestor de Projecto; Sponsor; Analista Sénior; Analista; Analista Júnior; Programador Sénior; Programador; Programador Júnior; Técnico de Qualidade; Testador Sénior; Testador | 44h | 2,540 |
| 23 | 2.1.3.2 | Relatório de Encerramento (2.2.3.3) |  | 0.5d? | 2005-06-01 | 2005-06-02 | 22 | 0d |  |  | Gestor de Projecto; Analista Sénior; Programador Sénior; Testador Sénior | 16h | 1,020 |
| 24 | 2.1.3.3 | Aceitação (sign.off) (2.2.3.2) |  | 0.5d? | 2005-06-02 | 2005-06-02 | 23 | 0d |  |  | Gestor de Projecto | 4h | 300 |

| ID | WBS | Task | Duration | Start | Finish | Predecessors | Total slack | Free slack | Resources | Work | Cost |
| --- | --- | --- | --- | --- | --- | --- | --- | --- | --- | --- | --- |
| 25 | 2.2 | **Processo Técnico** | 81.37d? | 2005-02-08 | 2005-06-01 | 9 | 0d |  |  | 836h | 46,378.67 |
| 26 | 2.2.1 | **Análise** | 34.42d? | 2005-02-08 | 2005-03-28 |  | 0d |  |  | 270h | 14,160 |
| 27 | 2.2.1.1 | **Análise de Dados (1.3)** | 21.58d? | 2005-02-08 | 2005-03-09 |  | 0d |  |  | 134h | 8,320 |
| 28 | 2.2.1.1.1 | **Modelação Dimensional (1.3.1)** | 9.67d? | 2005-02-08 | 2005-02-21 |  | 0d |  |  | 48h | 3,653.33 |
| 29 | 2.2.1.1.1.1 | Reunir com o cliente para levantar necessidades | 2d? | 2005-02-08 | 2005-02-09 |  | 0.67d |  | Analista Sénior [60%]; Analista [50%]; Viagem [1000 €] | 16h | 1,880 |
| 30 | 2.2.1.1.1.2 | Elaborar o documento | 2.67d? | 2005-02-08 | 2005-02-10 | 29FF | 0d |  | Analista [50%]; Analista Sénior [40%] | 16h | 853.33 |
| 31 | 2.2.1.1.1.3 | Enviar documento para Aprovação | 1d? | 2005-02-10 | 2005-02-11 | 30 | 0d |  | Analista Sénior | 8h | 480 |
| 32 | 2.2.1.1.1.4 | Rever e produzir documento Final | 1d? | 2005-02-18 | 2005-02-21 | 3 | 0d |  | Analista Sénior [50%]; Analista [50%] | 8h | 440 |
| 33 | 2.2.1.1.2 | **Módulo de Exportação de Dados na WEB (1.3.2)** | 9.42d? | 2005-02-21 | 2005-03-07 | 28 | 0d |  |  | 48h | 2,653.33 |
| 34 | 2.2.1.1.2.1 | Reunir para levantamento de requisitos | 2.22d? | 2005-02-21 | 2005-02-23 |  | 0.2d |  | Analista Sénior [60%]; Analista [45%] | 16h | 880 |
| 35 | 2.2.1.1.2.2 | Elaborar o documento | 2.42d? | 2005-02-21 | 2005-02-24 | 34FF | 0d |  | Analista [55%]; Analista Sénior [40%] | 16h | 853.33 |
| 36 | 2.2.1.1.2.3 | Enviar documento para Aprovação | 1d? | 2005-02-24 | 2005-02-25 | 35 | 0d |  | Analista Sénior | 8h | 480 |
| 37 | 2.2.1.1.2.4 | Rever e produzir documento Final | 1d? | 2005-03-04 | 2005-03-07 | 4 | 0d |  | Analista Sénior [50%]; Analista [50%] | 8h | 440 |
| 38 | 2.2.1.1.3 | **Modulo de Análise Parametrizado (1.3.3)** | 9.39d? | 2005-02-24 | 2005-03-09 | 28 | 58.6d |  |  | 38h | 2,013.33 |
| 39 | 2.2.1.1.3.1 | Definr critéiros de análise | 1d? | 2005-02-24 | 2005-02-25 |  | 58.6d | 0.81d | Analista | 8h | 400 |
| 40 | 2.2.1.1.3.2 | Definir cenários de análise | 1.33d? | 2005-02-28 | 2005-03-01 | 39 | 59.79d | 0d | Analista Sénior [50%]; Analista | 16h | 853.33 |
| 41 | 2.2.1.1.3.3 | Definir os templates para reporting | 0.75d? | 2005-03-01 | 2005-03-02 | 40 | 59.79d | 0d | Analista | 6h | 300 |
| 42 | 2.2.1.1.3.4 | Envio para aprovação | 0.5d? | 2005-03-01 | 2005-03-02 | 41FF | 59.79d | 0d | Analista Sénior | 4h | 240 |
| 43 | 2.2.1.1.3.5 | Rever e produzir documento final | 0.5d? | 2005-03-09 | 2005-03-09 | 5 | 59.79d |  | Analista Sénior [50%]; Analista [50%] | 4h | 220 |
| 44 | 2.2.1.2 | **Caderno de Análise (2.1.1)** | 15.33d? | 2005-03-07 | 2005-03-28 | 33 | 0d |  |  | 136h | 5,840 |
| 45 | 2.2.1.2.1 | Elaborar diagrama de entidade e associações | 10d? | 2005-03-07 | 2005-03-21 |  | 3.33d |  | Analista Júnior [40%]; Analista [25%] | 40h | 1,680 |
| 46 | 2.2.1.2.2 | Elaborar diagrama de fluxo de dados | 13.33d? | 2005-03-07 | 2005-03-24 |  | 0d |  | Analista Júnior [60%]; Analista [25%] | 80h | 3,360 |
| 47 | 2.2.1.2.3 | Caracterizar entidades envolvidas | 2d? | 2005-03-24 | 2005-03-28 | 45, 46 | 0d |  | Analista | 16h | 800 |
| 48 | 2.2.2 | **Desenho** | 6.17d? | 2005-03-28 | 2005-04-05 |  | 0d |  |  | 72h | 3,240 |
| 49 | 2.2.2.1 | Especificação Funcional (2.1.2) | 3.33d? | 2005-03-28 | 2005-03-31 | 44 | 0d |  | Analista Sénior [25%]; Analista Júnior; Analista [25%] | 40h | 1,800 |
| 50 | 2.2.2.2 | Especificação Técnica (2.1.3) | 2.67d? | 2005-03-31 | 2005-04-05 | 49FS-2.5% | 0d |  | Analista Sénior [25%]; Analista Júnior; Analista [25%] | 32h | 1,440 |

Notes:
- 31: Compeltar o Glossário / Validar a Estrutura do Documento / Rever o Portugês / Validar Tipos de Letras / Transformar em PDF

| ID | WBS | Task | Duration | Start | Finish | Predecessors | Total slack | Resources | Work | Cost |
| --- | --- | --- | --- | --- | --- | --- | --- | --- | --- | --- |
| 51 | 2.2.3 | **Codificação** | 29.31d? | 2005-04-05 | 2005-05-16 | 48, 6 | 0d |  | 398h | 23,826.67 |
| 52 | 2.2.3.1 | **Sistema (1)** | 20.83d? | 2005-04-05 | 2005-05-04 |  | 0d |  | 278h | 18,146.67 |
| 53 | 2.2.3.1.1 | **Aquisição de Dados (1.1)** | 7.5d? | 2005-04-05 | 2005-04-15 |  | 0d |  | 98h | 9,613.33 |
| 54 | 2.2.3.1.1.1 | Recepção e Instalação do Servidor | 1d? | 2005-04-05 | 2005-04-06 |  | 0d | Programador; Servidor Alpha [1 P IV x 2] | 8h | 5,400 |
| 55 | 2.2.3.1.1.2 | Validação de Dados (1.1.1) | 1.67d? | 2005-04-06 | 2005-04-08 | 54 | 4.83d | Programador Sénior [50%]; Programador Júnior | 20h | 933.33 |
| 56 | 2.2.3.1.1.3 | Estruturação de formatos e Regras (1.1.2) | 2.5d? | 2005-04-06 | 2005-04-11 | 54 | 0d | Programador Sénior [50%]; Programador | 30h | 1,600 |
| 57 | 2.2.3.1.1.4 | Interface e Entrada de Dados (1.1.3) | 4d? | 2005-04-11 | 2005-04-15 | 56 | 0d | Programador Júnior; Programador [25%] | 40h | 1,680 |
| 58 | 2.2.3.1.2 | **Transformação e Registo (1.2)** | 13.33d? | 2005-04-15 | 2005-05-04 | 53 | 0d |  | 180h | 8,533.33 |
| 59 | 2.2.3.1.2.1 | Base de Dados (1.2.1) | 3.33d? | 2005-04-15 | 2005-04-20 |  | 0d | Programador; Programador Júnior [50%] | 40h | 1,866.67 |
| 60 | 2.2.3.1.2.2 | Interfaces (1.2.2) | 6.67d? | 2005-04-20 | 2005-04-29 | 59 | 3.33d | Programador Júnior; Programador [50%] | 80h | 3,466.67 |
| 61 | 2.2.3.1.2.3 | Processamento de Regras (1.2.3) | 10d? | 2005-04-20 | 2005-05-04 | 59 | 0d | Programador Sénior [50%]; Programador [50%] | 60h | 3,200 |
| 62 | 2.2.3.2 | **Manuais (2.1.5)** | 24.47d? | 2005-04-12 | 2005-05-16 |  | 0d |  | 120h | 5,680 |
| 63 | 2.2.3.2.1 | Manual de Exploração (2.1.5.1) | 8d? | 2005-05-04 | 2005-05-16 | 52 | 0d | Técnico de Qualidade [25%]; Programador [30%] | 24h | 1,200 |
| 64 | 2.2.3.2.2 | Manual do Utilizador (2.1.5.2) | 4d? | 2005-05-04 | 2005-05-10 | 52 | 4.47d | Técnico de Qualidade [25%]; Programador Júnior | 40h | 1,680 |
| 65 | 2.2.3.2.3 | Manual de Testes (2.1.5.3) | 16d? | 2005-04-12 | 2005-05-04 | 58FF | 8.47d | Técnico de Qualidade [25%]; Testador [25%] | 40h | 2,000 |
| 66 | 2.2.3.2.4 | Manual de Instalação (2.1.5.4) | 5.33d? | 2005-05-06 | 2005-05-13 | 52 | 1.14d | Técnico de Qualidade [25%]; Programador [30%] | 16h | 800 |
| 67 | 2.2.4 | **Testes** | 18.8d? | 2005-05-05 | 2005-06-01 | 51FS-2.5% | 0d |  | 96h | 5,152 |
| 68 | 2.2.4.1 | Relatório de Execução de Testes (2.1.4) | 2.13d? | 2005-05-05 | 2005-05-09 |  | 0d | Testador Sénior [25%]; Testador [75%] | 16h | 832 |
| 69 | 2.2.4.2 | **Formação (3)** | 16.67d? | 2005-05-09 | 2005-06-01 | 68 | 0d |  | 80h | 4,320 |
| 70 | 2.2.4.2.1 | **Utilizador (3.1)** | 10d? | 2005-05-09 | 2005-05-23 |  | 6.67d |  | 24h | 1,360 |
| 71 | 2.2.4.2.1.1 | Extranet (3.1.1) | 10d? | 2005-05-09 | 2005-05-23 |  | 6.67d | Programador [10%] | 8h | 400 |
| 72 | 2.2.4.2.1.2 | Análise de Dados (3.1.2) | 2d? | 2005-05-09 | 2005-05-11 |  | 14.67d | Programador Sénior | 16h | 960 |
| 73 | 2.2.4.2.2 | Formadores (3.2) | 2d? | 2005-05-09 | 2005-05-11 |  | 14.67d | Analista Sénior | 16h | 960 |
| 74 | 2.2.4.2.3 | Técnica (3.3) | 16.67d? | 2005-05-09 | 2005-06-01 |  | 0d | Programador [30%] | 40h | 2,000 |

| ID | WBS | Task | Type | Duration | Start | Finish | Predecessors | Total slack | Free slack | Deadline |
| --- | --- | --- | --- | --- | --- | --- | --- | --- | --- | --- |
| 75 | 3 | **Milestone Chart** |  | 79.21d | 2005-02-11 | 2005-06-02 |  | 0d |  |  |
| 76 | 3.1 | Envio Modelo Dimensional | milestone | 0d | 2005-02-11 | 2005-02-11 | 31 | 0d |  |  |
| 77 | 3.2 | Envio do Módulo de Exportação de Dados | milestone | 0d | 2005-02-25 | 2005-02-25 | 36 | 0d |  |  |
| 78 | 3.3 | Envio Modulo de Análise Parametrizado | milestone | 0d | 2005-03-02 | 2005-03-02 | 42 | 59.79d | 0d |  |
| 79 | 3.4 | Fim da Fase de Análise | milestone | 0d | 2005-03-28 | 2005-03-28 | 26 | 48.45d |  |  |
| 80 | 3.5 | Fim da Fase de Desenho | milestone | 0d | 2005-04-05 | 2005-04-05 | 48 | 42.28d |  |  |
| 81 | 3.6 | Fim de Projecto | milestone | 0d | 2005-06-02 | 2005-06-02 | 7 | 0d |  | 2005-08-01 |
